# OBRAS ARQUITECTURA Y PAISAJISMO

Schedule from Primavera P6, 2024-04-16 to 2024-11-13, data date 2024-04-16.

## Calendars

- PROY_LACRAMARCA: Mon-Sat 09:00-13:00, 15:00-19:00; Sun off.

## Schedule

| ID | WBS | Activity | Duration | Start | Finish | Predecessors | Total float | Free float |
| --- | --- | --- | --- | --- | --- | --- | --- | --- |
|  | 01 | **OBRAS PRELIMINARES** |  | 2024-04-16 | 2024-04-25 |  |  |  |
| A1000 |  | INSTALACIONES PROVISIONALES PARA LA OBRA | 9d | 2024-04-16 | 2024-04-25 |  | 0d |  |
|  | 02 | **ARQUITECTURA Y PAISAJISMO** |  | 2024-04-16 | 2024-11-13 |  |  |  |
|  | 01 | **INTERVENCIÓN PAISAJISMO - HUMEDAL VILLA MARIA MARGEN DERECHO** |  | 2024-04-16 | 2024-11-13 |  |  |  |
|  | 01 | **OBRAS PRELIMINARES** |  | 2024-04-16 | 2024-10-24 |  |  |  |
| A1010 |  | MOVILIZACIÓN Y DEMOVILIZACIÓN DE EQUIPOS Y HERRAMIENTAS (ARQUITECTURA Y PAISAJISMO) | 15d | 2024-04-16 | 2024-05-02 | A1000 SS | 17d | 0d |
| A1030 |  | ELIMINACION DE RESIDUOS SOLIDOS GENERALES MUNICIPALES | 66d | 2024-04-26 | 2024-07-11 | A1000 | 0d |  |
| A1020 |  | TRAZO Y REPLANTEO PRELIMINAR | 150d | 2024-05-03 | 2024-10-24 | A1000, A1010 | 17d | 45d |
|  | 02 | **MOVIMIENTO DE TIERRAS** |  | 2024-06-26 | 2024-10-29 |  |  |  |
| A1040 |  | CORTE PARA CIMENTACIÓN DE DIQUE NATURALIZADO h=30cm | 15d | 2024-06-26 | 2024-07-12 | A1030 SS+52d, A1020 SS+1d | 0d |  |
| A1050 |  | PERFILADO Y COMPACTACION EN ZONA DE CORTE | 12d | 2024-07-03 | 2024-07-16 | A1040 SS+6d | 0d |  |
| A1060 |  | CONFORMACIÓN DE CUERPO DE DIQUE NATURALZADO CON RELLENO COMPACTADO | 37d | 2024-07-17 | 2024-08-28 | A1050, A1030 | 0d |  |
| A1070 |  | EXCAVACIÓN MANUAL PARA INSTALACIÓN DE BORDILLOS Y CIMENTACIONES | 38d | 2024-08-29 | 2024-10-11 | A1060 | 4d | 0d |
| A1080 |  | EXCAVACIÓN PARA MEJORAMIENTO DE SUELO CON TIERRA VEGETAL | 2d | 2024-08-29 | 2024-08-30 | A1060 | 49d | 36d |
| A1090 |  | ELIMINACION DE MATERIAL EXCEDENTE (DME´S) | 15d | 2024-10-12 | 2024-10-29 | A1040, A1070, A1080 | 13d |  |
|  | 03 | **PAVIMENTOS, RECUBRIMIENTOS Y BORDILLOS** |  | 2024-10-03 | 2024-11-12 |  |  |  |
| A1100 |  | PISO TIERRA APISONADA (h=0.35cm) | 30d | 2024-10-03 | 2024-11-06 | A1190 | 0d |  |
| A1110 |  | RECUBRIMIENTO DE PIEDRA DEL LUGAR e=0.05cm | 10d | 2024-10-21 | 2024-10-31 | A1100 SS+15d, A1070 | 11d |  |
| A1120 |  | BORDILLOS DE PIEDRA DEL LUGAR | 20d | 2024-10-21 | 2024-11-12 | A1100 SS+15d, A1070 | 1d |  |
|  | 04 | **MOBILIARIOS, BARANDAS Y ESCALERAS** |  | 2024-10-17 | 2024-11-13 |  |  |  |
| A1170 |  | BOLARDOS DE PIEDRA | 24d | 2024-10-17 | 2024-11-13 | A1070, A1100 SS+12d | 0d |  |
| A1130 |  | TACHOS DE BASURA, INCLUYE CIMENTACIÓN | 20d | 2024-10-21 | 2024-11-12 | A1070, A1100 SS+15d | 1d |  |
| A1140 |  | BANCAS DE CONCRETO, INCLUYE CIMENTACIÓN | 15d | 2024-10-21 | 2024-11-06 | A1070, A1100 SS+15d | 6d |  |
| A1150 |  | POSTES DE ILUMINACION, INCLUYE LUMINARIA Y CIMENTACION | 20d | 2024-10-21 | 2024-11-12 | A1070, A1100 SS+15d | 1d |  |
| A1160 |  | SEÑALETICA INFORMATIVA | 10d | 2024-10-21 | 2024-10-31 | A1070, A1100 SS+15d | 11d |  |
| A1180 |  | TRANQUERA | 15d | 2024-10-21 | 2024-11-06 | A1070, A1100 SS+15d | 6d |  |

| ID | WBS | Activity | Duration | Start | Finish | Predecessors | Total float | Free float |
| --- | --- | --- | --- | --- | --- | --- | --- | --- |
|  | 05 | **OBRAS PRELIMINARES PAISAJISMO)** |  | 2024-08-29 | 2024-10-02 |  |  |  |
| A1190 |  | MEJORAMIENTO DE SUELO CON TIERRA DE CHACRA (incluye despedregado y rastrillado) | 30d | 2024-08-29 | 2024-10-02 | A1060 | 0d |  |
|  | 02 | **INTERVENCIÓN PAISAJISMO - HUMEDAL VILLA MARIA MARGEN IZQUIERDO** |  | 2024-04-16 | 2024-11-13 |  |  |  |
|  | 01 | **OBRAS PRELIMINARES** |  | 2024-04-16 | 2024-06-20 |  |  |  |
| A1200 |  | MOVILIZACIÓN Y DEMOVILIZACIÓN DE EQUIPOS Y HERRAMIENTAS (ARQUITECTURA Y PAISAJISMO) | 15d | 2024-04-16 | 2024-05-02 | A1010 SS | 166d | 0d |
| A1220 |  | ELIMINACION DE RESIDUOS SOLIDOS GENERALES MUNICIPALES | 48d | 2024-04-26 | 2024-06-20 | A1000 | 0d |  |
| A1210 |  | TRAZO Y REPLANTEO PRELIMINAR | 1d | 2024-05-03 | 2024-05-03 | A1000, A1200 | 166d |  |
|  | 02 | **MOVIMIENTO DE TIERRAS** |  | 2024-06-04 | 2024-10-18 |  |  |  |
| A1230 |  | CORTE PARA CIMENTACIÓN DE DIQUE NATURALIZADO h=30cm | 35d | 2024-06-04 | 2024-07-13 | A1220 SS+33d | 0d |  |
| A1240 |  | PERFILADO Y COMPACTACION EN ZONA DE CORTE | 14d | 2024-07-09 | 2024-07-24 | A1230 SS+30d | 0d |  |
| A1250 |  | CONFORMACIÓN DE DIQUE NATURALIZADO O TERRAZA CON RELLENO COMPACTADO | 5d | 2024-07-25 | 2024-07-30 | A1240, A1220, A1040 | 0d |  |
| A1260 |  | EXCAVACIÓN MANUAL PARA INSTALACIÓN DE BORDILLOS Y CIMENTACIONES | 12d | 2024-07-31 | 2024-08-13 | A1250 | 44d | 22d |
| A1270 |  | ELIMINACION DE MATERIAL EXCEDENTE (DME´S) | 35d | 2024-09-09 | 2024-10-18 | A1260, A1230, A1280 | 22d |  |
|  | 03 | **PAVIMENTOS, RECUBRIMIENTOS Y BORDILLOS** |  | 2024-08-26 | 2024-10-01 |  |  |  |
| A1280 |  | PISO TIERRA APISONADA (h=0.35cm) | 12d | 2024-08-26 | 2024-09-07 | A1370 | 0d |  |
| A1290 |  | RECUBRIMIENTO DE PIEDRA DEL LUGAR e=0.05cm | 7d | 2024-09-09 | 2024-09-16 | A1280 | 50d |  |
| A1300 |  | BORDILLOS DE PIEDRA DEL LUGAR | 20d | 2024-09-09 | 2024-10-01 | A1280 | 37d |  |
|  | 04 | **MOBILIARIOS, BARANDAS Y ESCALERAS** |  | 2024-08-31 | 2024-11-13 |  |  |  |
| A1310 |  | TACHOS DE BASURA, INCLUYE CIMENTACIÓN | 25d | 2024-08-31 | 2024-09-28 | A1280 SS+5d | 39d |  |
| A1320 |  | BANCAS DE CONCRETO, INCLUYE CIMENTACIÓN | 15d | 2024-08-31 | 2024-09-17 | A1280 SS+5d | 49d |  |
| A1330 |  | POSTES DE ILUMINACION, INCLUYE LUMINARIA Y CIMENTACION | 25d | 2024-08-31 | 2024-09-28 | A1280 SS+5d | 39d |  |
| A1340 |  | SEÑALETICA INFORMATIVA | 10d | 2024-08-31 | 2024-09-11 | A1280 SS+5d | 54d |  |
| A1350 |  | BOLARDOS DE PIEDRA | 64d | 2024-08-31 | 2024-11-13 | A1280 SS+5d | 0d |  |
| A1360 |  | TRANQUERA | 15d | 2024-08-31 | 2024-09-17 | A1280 SS+5d | 49d |  |

| ID | WBS | Activity | Duration | Start | Finish | Predecessors | Total float |
| --- | --- | --- | --- | --- | --- | --- | --- |
|  | 05 | **OBRAS PRELIMINARES PAISAJISMO** |  | 2024-07-31 | 2024-08-24 |  |  |
| A1370 |  | MEJORAMIENTO DE SUELO CON TIERRA DE CHACRA (incluye despedregado y rastrillado) | 22d | 2024-07-31 | 2024-08-24 | A1250 | 0d |
